# ssi-project2013-example_11

How a schedule from MS Project changed from version to version. A marks actual dates.

## Version 1 (saved 2013-04-04, file ssi-project2013-example-11.mpp)

| ID | WBS | Task | Duration | Start | Finish | Predecessors | Total float | Constraint |
| --- | --- | --- | --- | --- | --- | --- | --- | --- |
| 1 | 1 | **Prepare site** | 10d | 2013-04-02 09:00 | 2013-04-15 18:00 |  | 8.25d |  |
| 2 |  | Demolition | 5d | 2013-04-02 09:00 | 2013-04-08 18:00 |  | 8.25d | start no earlier than 2013-04-02 08:00 |
| 3 |  | Set out site | 1d | 2013-04-09 09:00 | 2013-04-09 18:00 | 2 | 8.25d | start no earlier than 2013-04-02 08:00 |
| 4 |  | Inground plumbing | 2d | 2013-04-10 09:00 | 2013-04-11 18:00 | 3 | 8.25d | start no earlier than 2013-04-02 08:00 |
| 5 |  | Excavation | 2d | 2013-04-12 09:00 | 2013-04-15 18:00 | 4 | 8.25d | start no earlier than 2013-04-02 08:00 |
| 6 |  | Site prepared | 0d | 2013-04-15 18:00 | 2013-04-15 18:00 | 1 | 43.25d | start no earlier than 2013-04-03 08:00 |
| 7 | 3 | **Site Inspection** | 53.25d | 2013-04-02 09:00 | 2013-06-18 11:00 |  | 0d |  |
| 8 |  | Site Inspection 1 | 2h | 2013-04-02 09:00 | 2013-04-02 11:00 |  | 53d | start no earlier than 2013-04-02 09:00 |
| 9 |  | Site Inspection 2 | 2h | 2013-04-09 09:00 | 2013-04-09 11:00 |  | 48d | start no earlier than 2013-04-09 09:00 |
| 10 |  | Site Inspection 3 | 2h | 2013-04-16 09:00 | 2013-04-16 11:00 |  | 43d | start no earlier than 2013-04-16 09:00 |
| 11 |  | Site Inspection 4 | 2h | 2013-04-23 09:00 | 2013-04-23 11:00 |  | 38d | start no earlier than 2013-04-23 09:00 |
| 12 |  | Site Inspection 5 | 2h | 2013-04-30 09:00 | 2013-04-30 11:00 |  | 33d | start no earlier than 2013-04-30 09:00 |
| 13 |  | Site Inspection 6 | 2h | 2013-05-07 09:00 | 2013-05-07 11:00 |  | 29d | start no earlier than 2013-05-07 09:00 |
| 14 |  | Site Inspection 7 | 2h | 2013-05-14 09:00 | 2013-05-14 11:00 |  | 24d | start no earlier than 2013-05-14 09:00 |
| 15 |  | Site Inspection 8 | 2h | 2013-05-21 09:00 | 2013-05-21 11:00 |  | 19d | start no earlier than 2013-05-21 09:00 |
| 16 |  | Site Inspection 9 | 2h | 2013-05-28 09:00 | 2013-05-28 11:00 |  | 15d | start no earlier than 2013-05-28 09:00 |
| 17 |  | Site Inspection 10 | 2h | 2013-06-04 09:00 | 2013-06-04 11:00 |  | 10d | start no earlier than 2013-06-04 09:00 |
| 18 |  | Site Inspection 11 | 2h | 2013-06-11 09:00 | 2013-06-11 11:00 |  | 5d | start no earlier than 2013-06-11 09:00 |
| 19 |  | Site Inspection 12 | 2h | 2013-06-18 09:00 | 2013-06-18 11:00 |  | 0d | start no earlier than 2013-06-18 09:00 |
| 20 | 4 | **Lay foundation** | 11d | 2013-04-16 09:00 | 2013-04-30 18:00 | 1 | 8.25d |  |
| 21 |  | Footings and slabs | 3d | 2013-04-16 09:00 | 2013-04-18 18:00 |  | 8.25d | start no earlier than 2013-04-03 08:00 |
| 22 |  | Base brickwork | 2d | 2013-04-19 09:00 | 2013-04-22 18:00 | 21 | 8.25d | start no earlier than 2013-04-03 08:00 |
| 23 |  | Sub floor | 4d | 2013-04-23 09:00 | 2013-04-26 18:00 | 22 | 8.25d | start no earlier than 2013-04-03 08:00 |
| 24 |  | Suspended plumbing | 2d | 2013-04-29 09:00 | 2013-04-30 18:00 | 23 | 8.25d | start no earlier than 2013-04-03 08:00 |
| 25 | 5 | **Build walls** | 10d | 2013-05-01 09:00 | 2013-05-15 18:00 | 20 | 8.25d |  |
| 26 |  | Ground floor walls | 5d | 2013-05-01 09:00 | 2013-05-08 18:00 |  | 8.25d | start no earlier than 2013-04-03 08:00 |
| 27 |  | Upper floor walls | 5d | 2013-05-09 09:00 | 2013-05-15 18:00 | 26 | 8.25d | start no earlier than 2013-04-03 08:00 |
| 28 | 6 | **Fit windows and doors** | 7d | 2013-05-16 09:00 | 2013-05-24 18:00 | 25 | 15.25d |  |
| 29 | 6.1 | **Fit doors** | 7d | 2013-05-16 09:00 | 2013-05-24 18:00 |  | 15.25d |  |
| 30 |  | Ground floor doors | 4d | 2013-05-21 09:00 | 2013-05-24 18:00 |  | 15.25d | start no earlier than 2013-04-02 08:00 |
| 31 |  | Upper floor doors | 2d | 2013-05-16 09:00 | 2013-05-17 18:00 |  | 20.25d | start no earlier than 2013-04-02 08:00 |
| 32 | 6.2 | **Fit windows** | 3d | 2013-05-16 09:00 | 2013-05-20 18:00 |  | 19.25d |  |
| 33 |  | Ground floor windows | 3d | 2013-05-16 09:00 | 2013-05-20 18:00 |  | 19.25d | start no earlier than 2013-04-02 08:00 |
| 34 |  | Upper floor windows | 3d | 2013-05-16 09:00 | 2013-05-20 18:00 |  | 19.25d | start no earlier than 2013-04-02 08:00 |
| 35 | 7 | **Fit roof** | 14d | 2013-05-16 09:00 | 2013-06-05 18:00 | 25 | 8.25d |  |
| 36 |  | Trusses and frame | 5d | 2013-05-16 09:00 | 2013-05-22 18:00 |  | 8.25d | start no earlier than 2013-04-03 08:00 |
| 37 |  | Lining and tiles | 6d | 2013-05-23 09:00 | 2013-05-31 18:00 | 36 | 8.25d | start no earlier than 2013-04-03 08:00 |
| 38 |  | Finishing | 3d | 2013-06-03 09:00 | 2013-06-05 18:00 | 37 | 8.25d | start no earlier than 2013-04-03 08:00 |
| 39 |  | Building Complete | 0d | 2013-06-05 18:00 | 2013-06-05 18:00 | 35 | 8.25d | start no earlier than 2013-04-03 08:00 |

## Version 2 (saved 2013-04-05, file ssi-project2013-example-12.mpp)

Last finish stays 2013-06-18.

Changed:

| ID | Task | Other |
| --- | --- | --- |
| 2 | Demolition | resources none → Laborer |
| 3 | Set out site | resources none → Laborer |
| 4 | Inground plumbing | resources none → Laborer |
| 5 | Excavation | resources Ground Pump; Ground Pump fuel [1 litre] → Ground Pump; Ground Pump fuel [1 litre]; Laborer |
| 8 | Site Inspection 1 | resources none → Site Foreman; Toby Arnott |
| 9 | Site Inspection 2 | resources none → Site Foreman; Toby Arnott |
| 10 | Site Inspection 3 | resources none → Site Foreman; Toby Arnott |
| 11 | Site Inspection 4 | resources none → Site Foreman; Toby Arnott |
| 12 | Site Inspection 5 | resources none → Site Foreman; Toby Arnott |
| 13 | Site Inspection 6 | resources none → Site Foreman; Toby Arnott |
| 14 | Site Inspection 7 | resources none → Site Foreman; Toby Arnott |
| 15 | Site Inspection 8 | resources none → Site Foreman; Toby Arnott |
| 16 | Site Inspection 9 | resources none → Site Foreman; Toby Arnott |
| 17 | Site Inspection 10 | resources none → Site Foreman; Toby Arnott |
| 18 | Site Inspection 11 | resources none → Site Foreman; Toby Arnott |
| 19 | Site Inspection 12 | resources none → Site Foreman; Toby Arnott |
| 21 | Footings and slabs | resources none → Laborer |
| 22 | Base brickwork | resources none → Bricklayer |
| 23 | Sub floor | resources none → Laborer |
| 24 | Suspended plumbing | resources none → Laborer |
| 36 | Trusses and frame | resources none → Roofer |
| 37 | Lining and tiles | resources none → Roofer |
| 38 | Finishing | resources none → Roofer |

## Version 3 (saved 2013-04-08, file ssi-project2013-example-13.mpp)

Last finish stays 2013-06-18.

Changed:

| ID | Task | Start | Finish | Duration | Total float | Predecessors | Other |
| --- | --- | --- | --- | --- | --- | --- | --- |
| 15 | Demolition |  |  |  | 8.25d → 0d |  | constraint start no earlier than 2013-04-02 08:00 → none |
| 16 | Set out site |  |  |  | 8.25d → 0d |  | constraint start no earlier than 2013-04-02 08:00 → none |
| 17 | Inground plumbing |  |  |  | 8.25d → 0d |  | constraint start no earlier than 2013-04-02 08:00 → none |
| 18 | Excavation |  |  |  | 8.25d → 0d |  | constraint start no earlier than 2013-04-02 08:00 → none |
| 20 | **Lay foundation** |  | 2013-04-30 18:00 → 2013-04-26 18:00 (-4d) | 11d → 9d | 8.25d → 0d |  |  |
| 21 | Footings and slabs |  |  |  | 8.25d → 0d |  | constraint start no earlier than 2013-04-03 08:00 → none |
| 22 | Base brickwork |  |  |  | 8.25d → 0d |  | constraint start no earlier than 2013-04-03 08:00 → none |
| 23 | Sub floor |  |  |  | 8.25d → 0d |  | constraint start no earlier than 2013-04-03 08:00 → none |
| 24 | Suspended plumbing | 2013-04-29 09:00 → 2013-04-25 09:00 (-4d) | 2013-04-30 18:00 → 2013-04-26 18:00 (-4d) |  | 8.25d → 0d | 23 → 23SS+2d | constraint start no earlier than 2013-04-03 08:00 → none; resources Laborer → Plumber |
| 25 | **Build walls** | 2013-05-01 09:00 → 2013-04-29 09:00 (-2d) | 2013-05-15 18:00 → 2013-05-13 18:00 (-2d) |  | 8.25d → 0d |  | resources Bricklayer; Bricks [12 000s] → none |
| 26 | Ground floor walls | 2013-05-01 09:00 → 2013-04-29 09:00 (-2d) | 2013-05-08 18:00 → 2013-05-03 18:00 (-5d) |  | 8.25d → 0d |  | constraint start no earlier than 2013-04-03 08:00 → none; resources Jim Stansfield → Jim Stansfield; Bricks [6 000s] |
| 27 | Upper floor walls | 2013-05-09 09:00 → 2013-05-07 09:00 (-2d) | 2013-05-15 18:00 → 2013-05-13 18:00 (-2d) |  | 8.25d → 0d |  | constraint start no earlier than 2013-04-03 08:00 → none; resources Jim Stansfield → Jim Stansfield; Bricks [6 000s] |
| 28 | **Fit windows and doors** | 2013-05-16 09:00 → 2013-05-07 09:00 (-9d) | 2013-05-24 18:00 → 2013-05-22 18:00 (-2d) | 7d → 12d | 15.25d → 17.25d | 25 → none | resources none → Glazing Inspector |
| 29 | **Fit doors** | 2013-05-16 09:00 → 2013-05-10 09:00 (-6d) | 2013-05-24 18:00 → 2013-05-22 18:00 (-2d) | 7d → 9d | 15.25d → 17.25d |  |  |
| 30 | Ground floor doors | 2013-05-21 09:00 → 2013-05-10 09:00 (-11d) | 2013-05-24 18:00 → 2013-05-20 18:00 (-4d) |  | 15.25d → 19.25d | none → 26 | constraint start no earlier than 2013-04-02 08:00 → none |
| 31 | Upper floor doors | 2013-05-16 09:00 → 2013-05-21 09:00 (+5d) | 2013-05-17 18:00 → 2013-05-22 18:00 (+5d) |  | 20.25d → 17.25d | none → 27 | constraint start no earlier than 2013-04-02 08:00 → none |
| 32 | **Fit windows** | 2013-05-16 09:00 → 2013-05-07 09:00 (-9d) | 2013-05-20 18:00 → 2013-05-16 18:00 (-4d) | 3d → 8d | 19.25d → 21.25d |  |  |
| 33 | Ground floor windows | 2013-05-16 09:00 → 2013-05-07 09:00 (-9d) | 2013-05-20 18:00 → 2013-05-09 18:00 (-11d) |  | 19.25d → 26.25d | none → 26 | constraint start no earlier than 2013-04-02 08:00 → none |
| 34 | Upper floor windows | 2013-05-16 09:00 → 2013-05-14 09:00 (-2d) | 2013-05-20 18:00 → 2013-05-16 18:00 (-4d) |  | 19.25d → 21.25d | none → 27 | constraint start no earlier than 2013-04-02 08:00 → none |
| 35 | **Fit roof** | 2013-05-16 09:00 → 2013-05-14 09:00 (-2d) | 2013-06-05 18:00 → 2013-05-31 18:00 (-5d) | 14d → 13d | 8.25d → 0d |  |  |
| 36 | Trusses and frame | 2013-05-16 09:00 → 2013-05-14 09:00 (-2d) | 2013-05-22 18:00 → 2013-05-20 18:00 (-2d) |  | 8.25d → 0d |  | constraint start no earlier than 2013-04-03 08:00 → start no earlier than 2013-05-13 09:00 |
| 37 | Lining and tiles | 2013-05-23 09:00 → 2013-05-21 09:00 (-2d) | 2013-05-31 18:00 → 2013-05-28 18:00 (-3d) | 6d → 5d | 8.25d → 0d |  | constraint start no earlier than 2013-04-03 08:00 → none |
| 38 | Finishing | 2013-06-03 09:00 → 2013-05-29 09:00 (-5d) | 2013-06-05 18:00 → 2013-05-31 18:00 (-5d) |  | 8.25d → 0d | 37 → 37FS-1d | constraint start no earlier than 2013-04-03 08:00 → none |
| 39 | Building Complete | 2013-06-05 18:00 → 2013-05-31 18:00 (-5d) | 2013-06-05 18:00 → 2013-05-31 18:00 (-5d) |  | 8.25d → 0d |  | constraint start no earlier than 2013-04-03 08:00 → none |

## Version 4 (saved 2013-04-08, file ssi-project2013-example-14.mpp)

Last finish stays 2013-06-18.

Changed:

| ID | Task | Other |
| --- | --- | --- |
| 1 | **Site Inspection** | baseline start none → 2013-04-02 09:00; baseline finish none → 2013-06-18 11:00 |
| 2 | Site Inspection 1 | baseline start none → 2013-04-02 09:00; baseline finish none → 2013-04-02 11:00 |
| 3 | Site Inspection 2 | baseline start none → 2013-04-09 09:00; baseline finish none → 2013-04-09 11:00 |
| 4 | Site Inspection 3 | baseline start none → 2013-04-16 09:00; baseline finish none → 2013-04-16 11:00 |
| 5 | Site Inspection 4 | baseline start none → 2013-04-23 09:00; baseline finish none → 2013-04-23 11:00 |
| 6 | Site Inspection 5 | baseline start none → 2013-04-30 09:00; baseline finish none → 2013-04-30 11:00 |
| 7 | Site Inspection 6 | baseline start none → 2013-05-07 09:00; baseline finish none → 2013-05-07 11:00 |
| 8 | Site Inspection 7 | baseline start none → 2013-05-14 09:00; baseline finish none → 2013-05-14 11:00 |
| 9 | Site Inspection 8 | baseline start none → 2013-05-21 09:00; baseline finish none → 2013-05-21 11:00 |
| 10 | Site Inspection 9 | baseline start none → 2013-05-28 09:00; baseline finish none → 2013-05-28 11:00 |
| 11 | Site Inspection 10 | baseline start none → 2013-06-04 09:00; baseline finish none → 2013-06-04 11:00 |
| 12 | Site Inspection 11 | baseline start none → 2013-06-11 09:00; baseline finish none → 2013-06-11 11:00 |
| 13 | Site Inspection 12 | baseline start none → 2013-06-18 09:00; baseline finish none → 2013-06-18 11:00 |
| 14 | **Prepare site** | baseline start none → 2013-04-02 09:00; baseline finish none → 2013-04-15 18:00 |
| 15 | Demolition | baseline start none → 2013-04-02 09:00; baseline finish none → 2013-04-08 18:00 |
| 16 | Set out site | baseline start none → 2013-04-09 09:00; baseline finish none → 2013-04-09 18:00 |
| 17 | Inground plumbing | baseline start none → 2013-04-10 09:00; baseline finish none → 2013-04-11 18:00 |
| 18 | Excavation | baseline start none → 2013-04-12 09:00; baseline finish none → 2013-04-15 18:00 |
| 19 | Site prepared | baseline start none → 2013-04-15 18:00; baseline finish none → 2013-04-15 18:00 |
| 20 | **Lay foundation** | baseline start none → 2013-04-16 09:00; baseline finish none → 2013-04-26 18:00 |
| 21 | Footings and slabs | baseline start none → 2013-04-16 09:00; baseline finish none → 2013-04-18 18:00 |
| 22 | Base brickwork | baseline start none → 2013-04-19 09:00; baseline finish none → 2013-04-22 18:00 |
| 23 | Sub floor | baseline start none → 2013-04-23 09:00; baseline finish none → 2013-04-26 18:00 |
| 24 | Suspended plumbing | baseline start none → 2013-04-25 09:00; baseline finish none → 2013-04-26 18:00 |
| 25 | **Build walls** | baseline start none → 2013-04-29 09:00; baseline finish none → 2013-05-13 18:00 |
| 26 | Ground floor walls | baseline start none → 2013-04-29 09:00; baseline finish none → 2013-05-03 18:00 |
| 27 | Upper floor walls | baseline start none → 2013-05-07 09:00; baseline finish none → 2013-05-13 18:00 |
| 28 | **Fit windows and doors** | baseline start none → 2013-05-07 09:00; baseline finish none → 2013-05-22 18:00 |
| 29 | **Fit doors** | baseline start none → 2013-05-10 09:00; baseline finish none → 2013-05-22 18:00 |
| 30 | Ground floor doors | baseline start none → 2013-05-10 09:00; baseline finish none → 2013-05-20 18:00 |
| 31 | Upper floor doors | baseline start none → 2013-05-21 09:00; baseline finish none → 2013-05-22 18:00 |
| 32 | **Fit windows** | baseline start none → 2013-05-07 09:00; baseline finish none → 2013-05-16 18:00 |
| 33 | Ground floor windows | baseline start none → 2013-05-07 09:00; baseline finish none → 2013-05-09 18:00 |
| 34 | Upper floor windows | baseline start none → 2013-05-14 09:00; baseline finish none → 2013-05-16 18:00 |
| 35 | **Fit roof** | baseline start none → 2013-05-14 09:00; baseline finish none → 2013-05-31 18:00 |
| 36 | Trusses and frame | baseline start none → 2013-05-14 09:00; baseline finish none → 2013-05-20 18:00 |
| 37 | Lining and tiles | baseline start none → 2013-05-21 09:00; baseline finish none → 2013-05-28 18:00 |
| 38 | Finishing | baseline start none → 2013-05-29 09:00; baseline finish none → 2013-05-31 18:00 |
| 39 | Building Complete | baseline start none → 2013-05-31 18:00; baseline finish none → 2013-05-31 18:00 |

## Version 5 (data date 2013-04-05, saved 2013-04-08, file ssi-project2013-example-15.mpp)

Last finish stays 2013-06-18. Complete tasks 0 → 1.

Changed:

| ID | Task | Start | Finish | Complete | Total float |
| --- | --- | --- | --- | --- | --- |
| 1 | **Site Inspection** | 2013-04-02 09:00 A |  | 0% → 8% |  |
| 2 | Site Inspection 1 | 2013-04-02 09:00 A | 2013-04-02 11:00 A | 0% → 100% | 53d → none |
| 14 | **Prepare site** | 2013-04-02 09:00 A |  | 0% → 40% |  |
| 15 | Demolition | 2013-04-02 09:00 A |  | 0% → 80% |  |

## Version 6 (data date 2013-04-12, saved 2013-04-08, file ssi-project2013-example-16.mpp)

Last finish stays 2013-06-18. Complete tasks 1 → 5.

Changed:

| ID | Task | Start | Finish | Complete | Total float |
| --- | --- | --- | --- | --- | --- |
| 1 | **Site Inspection** |  |  | 8% → 17% |  |
| 3 | Site Inspection 2 | 2013-04-09 09:00 A | 2013-04-09 11:00 A | 0% → 100% | 48d → none |
| 14 | **Prepare site** |  |  | 40% → 90% |  |
| 15 | Demolition |  | 2013-04-08 18:00 A | 80% → 100% | 0d → none |
| 16 | Set out site | 2013-04-09 09:00 A | 2013-04-09 18:00 A | 0% → 100% | 0d → none |
| 17 | Inground plumbing | 2013-04-10 09:00 A | 2013-04-11 18:00 A | 0% → 100% | 0d → none |
| 18 | Excavation | 2013-04-12 09:00 A |  | 0% → 50% |  |

## Version 7 (data date 2013-04-18, saved 2013-04-09, file ssi-project2013-example-17.mpp)

Last finish stays 2013-06-18. Complete tasks 5 → 6.

Changed:

| ID | Task | Start | Finish | Duration | Complete | Total float | Other |
| --- | --- | --- | --- | --- | --- | --- | --- |
| 1 | **Site Inspection** |  |  |  | 17% → 25% |  |  |
| 4 | Site Inspection 3 | 2013-04-16 09:00 A | 2013-04-16 11:00 A |  | 0% → 100% | 43d → none |  |
| 14 | **Prepare site** |  | 2013-04-15 18:00 → 2013-04-19 13:00 (+4d) | 10d → 13.5d | 90% → 95% | 0d → -1d |  |
| 18 | Excavation |  | 2013-04-15 18:00 → 2013-04-19 13:00 (+4d) |  | 50% → 75% | 0d → -1d |  |
| 19 | Site prepared | 2013-04-15 18:00 → 2013-04-19 13:00 (+4d) | 2013-04-15 18:00 → 2013-04-19 13:00 (+4d) |  |  | 43.25d → 39.75d | constraint start no earlier than 2013-04-03 08:00 → start no earlier than 2013-04-18 18:00 |
| 20 | **Lay foundation** | 2013-04-16 09:00 → 2013-04-19 14:00 (+3d) | 2013-04-26 18:00 → 2013-05-02 13:00 (+6d) |  |  | 0d → -1d |  |
| 21 | Footings and slabs | 2013-04-16 09:00 → 2013-04-19 14:00 (+3d) | 2013-04-18 18:00 → 2013-04-24 13:00 (+6d) |  |  | 0d → -1d | constraint none → start no earlier than 2013-04-18 18:00 |
| 22 | Base brickwork | 2013-04-19 09:00 → 2013-04-24 14:00 (+5d) | 2013-04-22 18:00 → 2013-04-26 13:00 (+4d) |  |  | 0d → -1d |  |
| 23 | Sub floor | 2013-04-23 09:00 → 2013-04-26 14:00 (+3d) | 2013-04-26 18:00 → 2013-05-02 13:00 (+6d) |  |  | 0d → -1d |  |
| 24 | Suspended plumbing | 2013-04-25 09:00 → 2013-04-30 14:00 (+5d) | 2013-04-26 18:00 → 2013-05-02 13:00 (+6d) |  |  | 0d → -1d |  |
| 25 | **Build walls** | 2013-04-29 09:00 → 2013-05-02 14:00 (+3d) | 2013-05-13 18:00 → 2013-05-14 18:00 (+1d) | 10d → 7.5d |  | 0d → -1d |  |
| 26 | Ground floor walls | 2013-04-29 09:00 → 2013-05-02 14:00 (+3d) | 2013-05-03 18:00 → 2013-05-07 18:00 (+4d) | 5d → 2.5d |  | 0d → -1d | resources Jim Stansfield; Bricks [6 000s] → Jim Stansfield; Bricks [6 000s]; Bricklayer |
| 27 | Upper floor walls | 2013-05-07 09:00 → 2013-05-08 09:00 (+1d) | 2013-05-13 18:00 → 2013-05-14 18:00 (+1d) |  |  | 0d → -1d |  |
| 28 | **Fit windows and doors** | 2013-05-07 09:00 → 2013-05-08 09:00 (+1d) | 2013-05-22 18:00 → 2013-05-29 18:00 (+7d) | 12d → 15d |  | 17.25d → 13.25d |  |
| 29 | **Fit doors** | 2013-05-10 09:00 → 2013-05-13 09:00 (+3d) | 2013-05-22 18:00 → 2013-05-29 18:00 (+7d) | 9d → 12d |  | 17.25d → 13.25d |  |
| 30 | Ground floor doors | 2013-05-10 09:00 → 2013-05-13 09:00 (+3d) | 2013-05-20 18:00 → 2013-05-16 18:00 (-4d) |  |  | 19.25d → 21.25d |  |
| 31 | Upper floor doors | 2013-05-21 09:00 → 2013-05-28 09:00 (+7d) | 2013-05-22 18:00 → 2013-05-29 18:00 (+7d) |  |  | 17.25d → 13.25d |  |
| 32 | **Fit windows** | 2013-05-07 09:00 → 2013-05-08 09:00 (+1d) | 2013-05-16 18:00 → 2013-05-24 18:00 (+8d) | 8d → 13d |  | 21.25d → 15.25d |  |
| 33 | Ground floor windows | 2013-05-07 09:00 → 2013-05-08 09:00 (+1d) | 2013-05-09 18:00 → 2013-05-10 18:00 (+1d) |  |  | 26.25d → 25.25d |  |
| 34 | Upper floor windows | 2013-05-14 09:00 → 2013-05-22 09:00 (+8d) | 2013-05-16 18:00 → 2013-05-24 18:00 (+8d) |  |  | 21.25d → 15.25d |  |
| 35 | **Fit roof** | 2013-05-14 09:00 → 2013-05-15 09:00 (+1d) | 2013-05-31 18:00 → 2013-06-03 18:00 (+3d) |  |  | 0d → -1d |  |
| 36 | Trusses and frame | 2013-05-14 09:00 → 2013-05-15 09:00 (+1d) | 2013-05-20 18:00 → 2013-05-21 18:00 (+1d) |  |  | 0d → -1d |  |
| 37 | Lining and tiles | 2013-05-21 09:00 → 2013-05-22 09:00 (+1d) | 2013-05-28 18:00 → 2013-05-29 18:00 (+1d) |  |  | 0d → -1d |  |
| 38 | Finishing | 2013-05-29 09:00 → 2013-05-30 09:00 (+1d) | 2013-05-31 18:00 → 2013-06-03 18:00 (+3d) |  |  | 0d → -1d |  |
| 39 | Building Complete | 2013-05-31 18:00 → 2013-06-03 18:00 (+3d) | 2013-05-31 18:00 → 2013-06-03 18:00 (+3d) |  |  | 0d → -1d |  |
